# 2017 Winter Shut Down Target Hall Schedule

Schedule from MS Project, 2016-11-24 to 2017-04-10, A marks actual dates.

## Calendars

- Standard: Mon-Fri 08:00-12:00, 13:00-17:00; Sat-Sun off.

## Resources

| Resource |
| --- |
| Anders Mjos |
| David Wang |
| Yasmine Saboui |
| Tavis Cave |
| Chad Fisher |
| Aurelia Laxdal |
| Vacuum Group |
| Grant Minor |
| Rob Walker |
| RPG |

## Schedule

| ID | Task | Duration | Start | Finish | Predecessors | Complete | Total slack | Free slack | Constraint | Resources | Work | Actual work |
| --- | --- | --- | --- | --- | --- | --- | --- | --- | --- | --- | --- | --- |
| 1 | Shielding Blocks Move- ITW to Storage Area | 1d | 2017-01-03 08:00 A | 2017-01-03 17:00 A |  | 100% |  |  | start no earlier than 2017-01-03 08:00 | David Wang | 8h | 8h |
| 2 | Anchor Bolts Clean out- Silo area | 1d | 2017-01-04 08:00 A | 2017-01-04 17:00 A |  | 100% |  |  | finish no earlier than 2017-01-04 17:00 | David Wang | 8h | 8h |
| 3 | Silos Re-arrangement | 2d | 2017-01-05 08:00 A | 2017-01-06 17:00 A | 2 | 100% |  |  | finish no earlier than 2017-01-06 17:00 | David Wang; Yasmine Saboui | 32h | 32h |
| 4 | Module Disconnection TM2- ITW( Except vacuum) | 1d | 2017-01-09 08:00 A | 2017-01-09 17:00 A | 3 | 100% |  |  | start no earlier than 2017-01-09 08:00 | David Wang | 8h | 8h |
| 5 | ITW and TM2 Shutdown Leak Check | 4d | 2017-01-10 08:00 A | 2017-01-13 17:00 A | 4 | 100% |  |  | finish no earlier than 2017-01-13 17:00 |  |  |  |
| 6 | Module Disconnection TM4-ITE(Except Vacuum) | 1d | 2017-01-16 08:00 A | 2017-01-16 17:00 A | 5 | 100% |  |  | start no earlier than 2017-01-16 08:00 | David Wang; Yasmine Saboui | 8h | 8h |
| 7 | ITE and TM4 Shut Down Leak Check | 2d | 2017-01-17 08:00 A | 2017-01-18 17:00 A | 6 | 100% |  |  | finish no earlier than 2017-01-11 17:00 | David Wang | 16h | 16h |
| 8 | Module Move-TM2- ITW to SHC | 0.25d | 2017-01-24 08:00 A | 2017-01-24 10:00 A | 7 | 100% |  |  | start no earlier than 2017-01-24 08:00 | Yasmine Saboui; David Wang | 4h | 4h |
| 9 | Febiad Target Installation/Leack Check | 0.25d | 2017-01-24 15:00 A | 2017-01-24 17:00 A | 8 | 100% |  |  | finish no earlier than 2017-01-24 17:00 | Chad Fisher | 2h | 2h |
| 10 | Module Move- TM2-SHC to TCS | 0.25d | 2017-01-24 08:00 A | 2017-01-24 10:00 A |  | 100% |  |  | start no earlier than 2017-01-24 08:00 | Yasmine Saboui; David Wang | 4h | 4h |
| 11 | Spent Target UCX Move- SHC to Storage Vault | 0.5d | 2017-01-25 08:00 A | 2017-01-25 12:00 A | 9 | 100% |  |  | start no earlier than 2017-01-25 08:00 | Yasmine Saboui; Chad Fisher | 8h | 8h |
| 12 | Module Move-TM4-ITE to SHC | 0.5d | 2017-01-25 13:00 A | 2017-01-25 17:00 A | 11 | 100% |  |  | finish no earlier than 2017-01-25 17:00 | Yasmine Saboui; David Wang | 8h | 8h |
| 13 | Module Move -TM4 - SHC to Silo | 0.5d | 2017-01-26 08:00 A | 2017-01-26 12:00 A | 12 | 100% |  |  | start no earlier than 2017-01-26 08:00 | Yasmine Saboui; David Wang | 8h | 8h |
| 14 | Spent Target Ta Move- SHC to Storage Vault | 0.5d | 2017-01-26 13:00 A | 2017-01-26 17:00 A | 13 | 100% |  |  | start no earlier than 2017-01-26 08:00 | Chad Fisher; David Wang; Yasmine Saboui | 12h | 12h |
| 15 | Module Move - TM2 - TCS to ITE | 0.5d | 2017-01-27 13:00 A | 2017-01-27 17:00 A | 14 | 100% |  |  | finish no earlier than 2017-01-27 17:00 | Yasmine Saboui; David Wang | 8h | 8h |
| 16 | Module Connection- TM2- ITE | 0.5d | 2017-01-27 08:00 A | 2017-01-27 12:00 A |  | 100% |  |  | start no earlier than 2017-01-27 08:00 | David Wang; Yasmine Saboui | 8h | 8h |
| 17 | Target Hall Crane Inspection | 3d | 2017-02-06 08:00 | 2017-02-08 17:00 |  |  | 41d |  | start no earlier than 2017-02-06 08:00 | Grant Minor | 24h |  |
| 18 | ITW TP4 Replacement | 1d | 2017-02-09 08:00 A | 2017-02-09 17:00 A |  | 100% |  |  | start no earlier than 2017-02-09 08:00 | Vacuum Group; David Wang | 16h | 16h |
| 19 | Clean up ITW | 1d | 2016-11-24 08:00 | 2016-11-24 17:00 |  |  | 97d |  |  |  |  |  |
| 20 | ISAC High Active Water Resin Can Replacement | 4d | 2017-03-02 08:00 | 2017-03-07 17:00 |  |  | 7d | 0d | start no earlier than 2017-03-02 08:00 | David Wang; Yasmine Saboui | 64h |  |
| 21 | ITW 2" Return Line Ball Valve Repairing | 1d | 2017-03-08 08:00 | 2017-03-08 17:00 | 20 |  | 7d |  | start no earlier than 2017-03-08 08:00 | David Wang | 8h |  |
| 22 | Spent Target Assay | 7d | 2017-03-09 08:00 | 2017-03-17 17:00 |  |  | 16d |  | finish no earlier than 2017-03-17 17:00 | Tavis Cave; RPG; Yasmine Saboui | 168h |  |
| 23 | Vacuum gauge Installlation on Turbo Back Line for ISAC Target Station | 5d | 2017-03-02 08:00 | 2017-03-08 17:00 |  |  | 23d |  | start no earlier than 2017-03-02 08:00 | Vacuum Group | 40h |  |
| 24 | Clean and ITE | 1d | 2017-03-20 08:00 | 2017-03-20 17:00 | 21 |  | 0d |  | start no earlier than 2017-03-20 08:00 | David Wang | 8h |  |
| 25 | ISAC Target Pit Module Move Ventilation | 15d | 2017-03-21 08:00 | 2017-04-10 17:00 | 24 |  | 0d |  | start no earlier than 2017-03-20 08:00 | Anders Mjos; Rob Walker; Vacuum Group | 360h |  |
